# SUBPROYECTO A2 TRAMO 2

Schedule from Primavera P6, 2023-12-17 to 2024-11-17, data date 2023-12-17.
Must finish by 2024-11-17

## Calendars

- 1T - 7x0 - 8 hr: Mon-Sun 08:00-16:00.

## Resources

| Resource | Group |
| --- | --- |
| HH | labor |

## Schedule

| ID | WBS | Activity | Type | Duration | Start | Finish | Predecessors | Total float | Free float | Resources |
| --- | --- | --- | --- | --- | --- | --- | --- | --- | --- | --- |
|  | 0 | **HITOS** |  |  | 2023-12-17 | 2024-11-17 |  |  |  |  |
| A1025 |  | KOM |  | 0d | 2023-12-17 | 2023-12-17 |  | 0d |  |  |
| A1015 |  | INICIO DE PLAZO CONTRACTUAL - ACCESO AL SITIO | milestone | 0d | 2024-01-02 | 2024-01-02 | A1025 FS+16d | 0d |  |  |
| A4240 |  | INICIO DE EXCAVACIÓN | milestone | 0d | 2024-01-07 | 2024-01-07 | A1015 SS+5d | 0d |  |  |
| A1016 |  | INICIO DE RELLENO DE DIQUE | milestone | 0d | 2024-01-29 | 2024-01-29 | A4240 SS+22d | 0d |  |  |
| A1020 |  | FIN DE PLAZO CONTRACTUAL | milestone | 0d | 2024-11-17 | 2024-11-17 | A1200, A1780, A1050, A4020, A3630, A3580, A3560, A3470, A3130, A3080, A2930, A2880, A1070 FF, A7140 FF, A7540 FF, A7440 FF, A3540 FF, A8120 FF, A3990 FF, A8090 FF, A5920 FF, A5900 FF, A5880 FF, A5440 FF, A1080 FF, A7690 FF, A5940 FF, A2910 FF, A3110 FF | 0d |  |  |
|  | 1 | **DEFENSAS RIBEREÑAS** |  |  | 2024-01-02 | 2024-11-17 |  |  |  |  |
|  | 1 | **OBRAS PRELIMINARES** |  |  | 2024-01-02 | 2024-11-15 |  |  |  |  |
| A1030 |  | CARTEL DE IDENTIFICACIÓN OBRA 4.80 x 3.60 m. |  | 2d | 2024-01-02 | 2024-01-03 | A1015 SS | 2d | 0d | HH [16 h] |
| A1040 |  | INSTALACIONES PROVISIONALES PARA LA OBRA |  | 4d | 2024-01-02 | 2024-01-05 | A1015 SS, A1030 SS | 2d | 0d | HH [32 h] |
| A1050 |  | MANTENIMIENTO DE TRÁNSITO Y SEGURIDAD VIAL |  | 315d | 2024-01-06 | 2024-11-15 | A1040 | 2d |  | HH [2520 h] |
|  | 2 | **TRABAJOS PRELIMINARES** |  |  | 2024-01-02 | 2024-11-17 |  |  |  |  |
| A1060 |  | MOVILIZACION DE EQUIPOS |  | 5d | 2024-01-02 | 2024-01-06 | A1015 SS | 2d | 0d | HH [40 h] |
| A1070 |  | TOPOGRAFÍA Y GEOREFERENCIACIÓN |  | 314d | 2024-01-07 | 2024-11-15 | A1040, A1060 | 2d |  | HH [2512 h] |
| A1080 |  | DESMOVILIZACION DE EQUIPOS |  | 9d | 2024-11-09 | 2024-11-17 | A7140 FF+2d | 0d |  | HH [72 h] |
|  | 3 | **MEJORAMIENTO DE VÍAS EXISTENTES** |  |  | 2024-01-07 | 2024-03-15 |  |  |  |  |
|  | 1 | **MOVIMIENTO DE TIERRAS** |  |  | 2024-01-07 | 2024-03-15 |  |  |  |  |
| A1090 |  | ROCE Y LIMPIEZA DE MALEZA |  | 3d | 2024-01-07 | 2024-01-09 | A4240 SS | 247d | 0d | HH [24 h] |
| A1100 |  | REHABILITACIÓN DE VÍAS EXISTENTES |  | 68d | 2024-01-08 | 2024-03-15 | A1090 SS+1d | 247d | 0d | HH [544 h] |
| A4220 |  | CONFORMACIÓN DE TERRAPLENES EN CAMINO |  | 3d | 2024-01-08 | 2024-01-10 | A1100 SS | 297d | 1d | HH [24 h] |
|  | 2 | **REPOSICIÓN DE ESTRUCTURAS** |  |  | 2024-01-12 | 2024-01-17 |  |  |  |  |
| A1160 |  | REPOSICIÓN DE PASE DE AGUA TUBO HDPE Ø=24" |  | 2d | 2024-01-12 | 2024-01-13 | A4240 SS+5d, A4220 | 296d | 0d | HH [16 h] |
| A1170 |  | REPOSICIÓN DE PASE DE AGUA TUBO HDPE Ø=18" |  | 2d | 2024-01-14 | 2024-01-15 | A1160 | 296d | 0d | HH [16 h] |
| A1180 |  | REPARACIÓN DE CONCRETO |  | 2d | 2024-01-16 | 2024-01-17 | A1170 SS+2d | 296d | 0d | HH [16 h] |

| ID | WBS | Activity | Duration | Start | Finish | Predecessors | Total float | Free float | Resources | Filtro |
| --- | --- | --- | --- | --- | --- | --- | --- | --- | --- | --- |
|  | 4 | **CABEZAL DE ENTRADA Y SALIDA** |  | 2024-01-24 | 2024-01-26 |  |  |  |  |  |
| A1210 |  | ENCOFRADO Y DESENCOFRADO NORMAL | 2d | 2024-01-24 | 2024-01-25 | A1180 SS+8d | 296d | 0d | HH [16 h] |  |
| A1200 |  | VACIADO DE CONCRETO 175kg/cm2 | 1d | 2024-01-26 | 2024-01-26 | A1210 | 296d |  | HH [8 h] |  |
|  | 4 | **DESCOLMATACIÓN DE CAUCE Y OBRAS AUXILIARES** |  | 2024-01-05 | 2024-11-11 |  |  |  |  |  |
|  | 1 | **DESBROCE Y DESCOLMATACIÓN** |  | 2024-01-05 | 2024-11-11 |  |  |  |  |  |
| A1220 |  | DESBROCE Y LIMPIEZA EN ZONA NO BOSCOSA | 300d | 2024-01-05 | 2024-10-30 | A1015 SS+3d | 6d | 0d | HH [2400 h] | Excavación |
| A5420 |  | DESCOLMATACIÓN DE CAUCE NATURAL DEL RÍO LACRAMARCA | 300d | 2024-01-10 | 2024-11-04 | A1220 SS+5d | 6d | 0d | HH |  |
| A5430 |  | CONFORMACIÓN DE DESVIO EN CAUCE DE RÍO | 296d | 2024-01-15 | 2024-11-05 | A5420 SS+5d | 6d | 0d |  |  |
| A5440 |  | RELLENO NO ESTRUCTURAL CON MATERIAL PROPIO | 297d | 2024-01-20 | 2024-11-11 | A5430 SS+5d | 6d |  |  |  |
|  | 5 | **DIQUES DE TIERRA COMPACTADA CON ENROCADO** |  | 2024-01-07 | 2024-11-15 |  |  |  |  |  |
|  | 2 | **DIQUE DE TIERRA COMPACTADA A2-I-7** |  | 2024-01-07 | 2024-10-24 |  |  |  |  |  |
|  | 22 | **DIQUE DE TIERRA COMPACTADA A2-I-07 - TRAMO SIN AFECTACIÓN** |  | 2024-01-07 | 2024-02-12 |  |  |  |  |  |
| A5780 |  | EXCAVACIÓN EN TERRENO NATURAL CON EQUIPO | 16d | 2024-01-07 | 2024-01-22 | A4240 SS | 2d | 0d | HH [128 h] | Excavación |
| A6100 |  | PERFILADO EN ZONA DE CORTE EN FUNDACION Y TALUD | 16d | 2024-01-08 | 2024-01-23 | A5780 FF+1d | 9d | 3d | HH [128 h] |  |
| A5790 |  | EXCAVACIÓN DE UÑA CON EQUIPO | 13d | 2024-01-12 | 2024-01-24 | A5780 FF+2d, A6100 SS+1d | 6d | 4d | HH [104 h] | Excavación |
| A5810 |  | PREPARACIÓN DE FUNDACIÓN DE CUERPO DE DIQUE | 3d | 2024-01-29 | 2024-01-31 | A5780 SS+1d, A1016 SS, A5790 | 2d | 0d | HH [24 h] |  |
| A5820 |  | CONFORMACIÓN DE CUERPO DE DIQUE CON MATERIAL PROPIO | 10d | 2024-01-30 | 2024-02-08 | A5810 SS+1d | 2d | 0d | HH [80 h] | Relleno |
| A5830 |  | GEOTEXTIL NO TEJIDO 400 G/M2, INC. COLOCACIÓN | 10d | 2024-01-31 | 2024-02-09 | A5820 SS+1d | 2d | 0d | HH [80 h] |  |
| A5840 |  | COLOCACION Y ACOMODO DE ROCA EN UÑA DE DIQUE | 12d | 2024-01-31 | 2024-02-11 | A5830 SS | 2d | 0d | HH [96 h] | Roca |
| A5850 |  | COLOCACION Y ACOMODO DE ROCA EN TALUD DE DIQUE | 12d | 2024-01-31 | 2024-02-11 | A5840 SS | 2d | 0d | HH [96 h] | Roca |
| A5800 |  | PERFILADO Y COMPACTACIÓN EN ZONA DE CORTE EN CORONA | 6d | 2024-02-07 | 2024-02-12 | A5850 SS+7d | 2d | 0d | HH [48 h] |  |
| A5860 |  | CONFORMACIÓN DE MATERIAL GRANULAR EN CORONA DE DIQUE | 6d | 2024-02-07 | 2024-02-12 | A5850 FF+1d, A5800 SS | 2d | 0d | HH [48 h] | Relleno |
|  | 21 | **DIQUE DE TIERRA COMPACTADA A2-I-07 - TRAMO CON AFECTACIÓN** |  | 2024-07-02 | 2024-09-05 |  |  |  |  |  |
| A6250 |  | EXCAVACIÓN EN TERRENO NATURAL CON EQUIPO | 35d | 2024-07-02 | 2024-08-05 | A6640, A5130 | 5d | 0d | HH [280 h] | Excavación |
| A6260 |  | PERFILADO EN ZONA DE CORTE EN FUNDACION Y TALUD | 35d | 2024-07-03 | 2024-08-06 | A6250 FF+1d | 15d | 10d | HH [72 h] |  |
| A6270 |  | EXCAVACIÓN DE UÑA CON EQUIPO | 24d | 2024-07-14 | 2024-08-06 | A6250 FF+1d, A6260 SS+1d | 5d | 0d | HH [192 h] | Excavación |
| A6290 |  | PREPARACIÓN DE FUNDACIÓN DE CUERPO DE DIQUE | 9d | 2024-07-14 | 2024-07-22 | A6250 SS+6d, A6270 SS | 5d | 0d | HH [72 h] |  |
| A6300 |  | CONFORMACIÓN DE CUERPO DE DIQUE CON MATERIAL PROPIO | 31d | 2024-07-15 | 2024-08-14 | A6290 SS+1d | 5d | 0d | HH [248 h] | Relleno |
| A6310 |  | GEOTEXTIL NO TEJIDO 400 G/M2, INC. COLOCACIÓN | 19d | 2024-07-29 | 2024-08-16 | A6300 FF+2d | 5d | 0d | HH [152 h] |  |
| A6320 |  | COLOCACION Y ACOMODO DE ROCA EN UÑA DE DIQUE | 38d | 2024-07-29 | 2024-09-04 | A6310 SS | 5d | 0d | HH [304 h] | Roca |
| A6330 |  | COLOCACION Y ACOMODO DE ROCA EN TALUD DE DIQUE | 38d | 2024-07-29 | 2024-09-04 | A6320 SS | 5d | 0d | HH [304 h] | Roca |
| A6280 |  | PERFILADO Y COMPACTACIÓN EN ZONA DE CORTE EN CORONA | 9d | 2024-08-16 | 2024-08-24 | A6330 SS+18d | 9d | 4d | HH [72 h] |  |
| A6340 |  | CONFORMACIÓN DE MATERIAL GRANULAR EN CORONA DE DIQUE | 17d | 2024-08-20 | 2024-09-05 | A6330 FF+1d, A6280 SS | 5d | 0d | HH [136 h] | Relleno |

| ID | WBS | Activity | Duration | Start | Finish | Predecessors | Total float | Free float | Resources | Filtro |
| --- | --- | --- | --- | --- | --- | --- | --- | --- | --- | --- |
|  | 19 | **DIQUE DE TIERRA COMPACTADA A2-I-07 - TRAMO POR LIBERAR 01 17+820** |  | 2024-10-13 | 2024-10-24 |  |  |  |  |  |
| A7350 |  | EXCAVACIÓN EN TERRENO NATURAL CON EQUIPO | 3d | 2024-10-13 | 2024-10-15 | A7590 | 5d | 0d | HH [24 h] | Excavación |
| A7360 |  | PERFILADO EN ZONA DE CORTE EN FUNDACION Y TALUD | 2d | 2024-10-14 | 2024-10-15 | A7350 SS+1d | 5d | 0d | HH [16 h] |  |
| A7370 |  | EXCAVACIÓN DE UÑA CON EQUIPO | 2d | 2024-10-15 | 2024-10-16 | A7350 FF, A7360 SS+1d | 5d | 0d | HH [16 h] | Excavación |
| A7380 |  | PREPARACIÓN DE FUNDACIÓN DE CUERPO DE DIQUE | 2d | 2024-10-17 | 2024-10-18 | A7350 SS+2d, A7370 SS+2d | 5d | 0d | HH [16 h] |  |
| A7400 |  | CONFORMACIÓN DE CUERPO DE DIQUE CON MATERIAL PROPIO | 3d | 2024-10-18 | 2024-10-20 | A7380 SS+1d | 5d | 0d | HH [24 h] | Relleno |
| A7410 |  | GEOTEXTIL NO TEJIDO 400 G/M2, INC. COLOCACIÓN | 2d | 2024-10-20 | 2024-10-21 | A7400 SS+2d | 5d | 0d | HH [16 h] |  |
| A7390 |  | PERFILADO Y COMPACTACIÓN EN ZONA DE CORTE EN CORONA | 3d | 2024-10-21 | 2024-10-23 | A7430 SS | 6d | 1d | HH [24 h] |  |
| A7420 |  | COLOCACION Y ACOMODO DE ROCA EN UÑA DE DIQUE | 3d | 2024-10-21 | 2024-10-23 | A7410 SS+1d | 5d | 0d | HH [24 h] | Roca |
| A7430 |  | COLOCACION Y ACOMODO DE ROCA EN TALUD DE DIQUE | 3d | 2024-10-21 | 2024-10-23 | A7420 SS | 5d | 0d | HH [24 h] | Roca |
| A7440 |  | CONFORMACIÓN DE MATERIAL GRANULAR EN CORONA DE DIQUE | 3d | 2024-10-22 | 2024-10-24 | A7430 FF+1d, A7390 SS | 5d | 0d | HH [24 h] | Relleno |
|  | 6 | **DIQUE DE TIERRA COMPACTADA A2-I-6** |  | 2024-01-07 | 2024-10-03 |  |  |  |  |  |
|  | 2 | **DIQUE DE TIERRA COMPACTADA A2-I-6 - TRAMO SIN AFECTACIÓN** |  | 2024-01-07 | 2024-02-15 |  |  |  |  |  |
| A7850 |  | EXCAVACIÓN EN TERRENO NATURAL CON EQUIPO | 16d | 2024-01-07 | 2024-01-22 | A4240 SS | 6d | 0d | HH [128 h] | Excavación |
| A7940 |  | PERFILADO EN ZONA DE CORTE EN FUNDACION Y TALUD | 8d | 2024-01-15 | 2024-01-22 | A7850 FF | 10d | 4d | HH [64 h] |  |
| A7860 |  | EXCAVACIÓN DE UÑA CON EQUIPO | 4d | 2024-01-20 | 2024-01-23 | A7850 FF+1d, A7940 SS+1d | 6d |  | HH [32 h] | Excavación |
| A7930 |  | PREPARACIÓN DE FUNDACIÓN DE CUERPO DE DIQUE | 2d | 2024-01-29 | 2024-01-30 | A7850 SS, A7860 SS+3d, A1016 SS | 0d |  | HH [16 h] |  |
| A7880 |  | CONFORMACIÓN DE CUERPO DE DIQUE CON MATERIAL PROPIO | 5d | 2024-01-30 | 2024-02-03 | A7930 SS+1d | 0d |  | HH [40 h] | Relleno |
| A7870 |  | PERFILADO Y COMPACTACIÓN EN ZONA DE CORTE EN CORONA | 2d | 2024-01-31 | 2024-02-01 | A7880 SS+1d | 0d |  | HH [16 h] |  |
| A7900 |  | GEOTEXTIL NO TEJIDO 400 G/M2, INC. COLOCACIÓN | 3d | 2024-02-01 | 2024-02-03 | A7880 SS+1d, A7870 SS+1d | 0d |  | HH [24 h] |  |
| A7910 |  | COLOCACION Y ACOMODO DE ROCA EN UÑA DE DIQUE | 7d | 2024-02-01 | 2024-02-07 | A7900 SS | 0d |  | HH [56 h] | Roca |
| A7920 |  | COLOCACION Y ACOMODO DE ROCA EN TALUD DE DIQUE | 14d | 2024-02-01 | 2024-02-14 | A7910 SS | 0d |  | HH [112 h] | Roca |
| A7890 |  | CONFORMACIÓN DE MATERIAL GRANULAR EN CORONA DE DIQUE | 3d | 2024-02-13 | 2024-02-15 | A7920 FF+1d | 0d |  | HH [24 h] | Relleno |
|  | 1 | **DIQUE DE TIERRA COMPACTADA A2-I-6 - TRAMO CON AFECTACIÓN** |  | 2024-09-06 | 2024-10-03 |  |  |  |  |  |
| A6650 |  | EXCAVACIÓN EN TERRENO NATURAL CON EQUIPO | 16d | 2024-09-06 | 2024-09-21 | A6340 | 5d | 0d | HH [128 h] | Excavación |
| A6660 |  | PERFILADO EN ZONA DE CORTE EN FUNDACION Y TALUD | 8d | 2024-09-14 | 2024-09-21 | A6650 FF | 9d | 4d | HH [64 h] |  |
| A6670 |  | EXCAVACIÓN DE UÑA CON EQUIPO | 4d | 2024-09-19 | 2024-09-22 | A6650 FF+1d, A6660 SS+1d | 5d | 0d | HH [32 h] | Excavación |
| A6680 |  | PREPARACIÓN DE FUNDACIÓN DE CUERPO DE DIQUE | 2d | 2024-09-22 | 2024-09-23 | A6650 SS, A6670 SS+3d | 5d | 0d | HH [16 h] |  |
| A6690 |  | CONFORMACIÓN DE CUERPO DE DIQUE CON MATERIAL PROPIO | 5d | 2024-09-23 | 2024-09-27 | A6680 SS+1d | 5d | 0d | HH [40 h] | Relleno |
| A6700 |  | PERFILADO Y COMPACTACIÓN EN ZONA DE CORTE EN CORONA | 2d | 2024-09-24 | 2024-09-25 | A6690 SS+1d | 5d | 0d | HH [16 h] |  |
| A6710 |  | GEOTEXTIL NO TEJIDO 400 G/M2, INC. COLOCACIÓN | 3d | 2024-09-25 | 2024-09-27 | A6690 SS+1d, A6700 SS+1d | 5d | 0d | HH [24 h] |  |
| A6720 |  | COLOCACION Y ACOMODO DE ROCA EN UÑA DE DIQUE | 7d | 2024-09-25 | 2024-10-01 | A6710 SS | 5d | 0d | HH [56 h] | Roca |
| A6730 |  | COLOCACION Y ACOMODO DE ROCA EN TALUD DE DIQUE | 8d | 2024-09-25 | 2024-10-02 | A6720 SS | 5d | 0d | HH [64 h] | Roca |
| A6740 |  | CONFORMACIÓN DE MATERIAL GRANULAR EN CORONA DE DIQUE | 3d | 2024-10-01 | 2024-10-03 | A6730 FF+1d | 5d | 0d | HH [24 h] | Relleno |

| ID | WBS | Activity | Duration | Start | Finish | Predecessors | Total float | Free float | Resources | Filtro |
| --- | --- | --- | --- | --- | --- | --- | --- | --- | --- | --- |
|  | 4 | **DIQUE DE TIERRA COMPACTADA A2-I-5** |  | 2024-02-16 | 2024-10-12 |  |  |  |  |  |
|  | 10 | **DIQUE DE TIERRA COMPACTADA A2-I-5 - TRAMO SIN AFECTACION** |  | 2024-02-16 | 2024-03-04 |  |  |  |  |  |
| A4600 |  | EXCAVACIÓN EN TERRENO NATURAL CON EQUIPO | 6d | 2024-02-16 | 2024-02-21 | A7890 | 0d |  | HH [48 h] | Excavación |
| A6030 |  | PERFILADO EN ZONA DE CORTE EN FUNDACION Y TALUD | 6d | 2024-02-20 | 2024-02-25 | A4600 SS+4d | 0d |  | HH [48 h] |  |
| A4610 |  | EXCAVACIÓN DE UÑA CON EQUIPO | 4d | 2024-02-21 | 2024-02-24 | A4600 FF, A6030 SS+1d | 0d |  | HH [32 h] | Excavación |
| A4650 |  | PREPARACIÓN DE FUNDACIÓN DE CUERPO DE DIQUE | 2d | 2024-02-23 | 2024-02-24 | A4600 SS, A4610 SS+2d | 0d |  | HH [16 h] |  |
| A4660 |  | CONFORMACIÓN DE CUERPO DE DIQUE CON MATERIAL PROPIO | 4d | 2024-02-24 | 2024-02-27 | A4650 SS+1d | 0d |  | HH [32 h] | Relleno |
| A4630 |  | GEOTEXTIL NO TEJIDO 400 G/M2, INC. COLOCACIÓN | 3d | 2024-02-25 | 2024-02-27 | A4660 SS+1d | 0d |  | HH [24 h] |  |
| A4640 |  | COLOCACION Y ACOMODO DE ROCA EN UÑA DE DIQUE | 6d | 2024-02-25 | 2024-03-01 | A4630 SS | 0d |  | HH [48 h] | Roca |
| A4670 |  | COLOCACION Y ACOMODO DE ROCA EN TALUD DE DIQUE | 7d | 2024-02-25 | 2024-03-02 | A4640 SS | 0d |  | HH [56 h] | Roca |
| A4620 |  | PERFILADO Y COMPACTACIÓN EN ZONA DE CORTE EN CORONA | 1d | 2024-03-02 | 2024-03-02 | A4670 SS+6d | 0d |  | HH [8 h] |  |
| A4680 |  | CONFORMACIÓN DE MATERIAL GRANULAR EN CORONA DE DIQUE | 3d | 2024-03-02 | 2024-03-04 | A4620 SS | 0d |  | HH [24 h] | Relleno |
|  | 1 | **DIQUE DE TIERRA COMPACTADA A2-I-5 - TRAMO CON AFECTACIÓN** |  | 2024-10-04 | 2024-10-12 |  |  |  |  |  |
| A7550 |  | EXCAVACIÓN EN TERRENO NATURAL CON EQUIPO | 3d | 2024-10-04 | 2024-10-06 | A6740 | 5d | 0d | HH [24 h] | Excavación |
| A7640 |  | PERFILADO EN ZONA DE CORTE EN FUNDACION Y TALUD | 3d | 2024-10-04 | 2024-10-06 | A7550 SS | 5d | 0d | HH [16 h] |  |
| A7560 |  | EXCAVACIÓN DE UÑA CON EQUIPO | 3d | 2024-10-05 | 2024-10-07 | A7550 FF+1d, A7640 SS+1d | 5d | 0d | HH [24 h] | Excavación |
| A7630 |  | PREPARACIÓN DE FUNDACIÓN DE CUERPO DE DIQUE | 3d | 2024-10-06 | 2024-10-08 | A7550 SS, A7560 SS+1d | 5d | 0d | HH [24 h] |  |
| A7580 |  | CONFORMACIÓN DE CUERPO DE DIQUE CON MATERIAL PROPIO | 3d | 2024-10-07 | 2024-10-09 | A7630 SS+1d | 5d | 0d | HH [24 h] | Relleno |
| A7600 |  | GEOTEXTIL NO TEJIDO 400 G/M2, INC. COLOCACIÓN | 3d | 2024-10-07 | 2024-10-09 | A7580 SS | 5d | 0d | HH [24 h] |  |
| A7610 |  | COLOCACION Y ACOMODO DE ROCA EN UÑA DE DIQUE | 3d | 2024-10-09 | 2024-10-11 | A7600 SS+2d | 5d | 0d | HH [24 h] | Roca |
| A7620 |  | COLOCACION Y ACOMODO DE ROCA EN TALUD DE DIQUE | 3d | 2024-10-09 | 2024-10-11 | A7610 SS | 5d | 0d | HH [24 h] | Roca |
| A7570 |  | PERFILADO Y COMPACTACIÓN EN ZONA DE CORTE EN CORONA | 3d | 2024-10-10 | 2024-10-12 | A7620 SS+1d | 5d | 0d | HH [24 h] |  |
| A7590 |  | CONFORMACIÓN DE MATERIAL GRANULAR EN CORONA DE DIQUE | 3d | 2024-10-10 | 2024-10-12 | A7620 FF+1d, A7570 SS | 5d | 0d | HH [24 h] | Relleno |
|  | 7 | **DIQUE DE TIERRA COMPACTADA A2-I-4** |  | 2024-03-05 | 2024-11-01 |  |  |  |  |  |
|  | 18 | **DIQUE DE TIERRA COMPACTADA A2-I-04 - TRAMO SIN AFECTACIÓN** |  | 2024-03-05 | 2024-04-15 |  |  |  |  |  |
| A6350 |  | EXCAVACIÓN EN TERRENO NATURAL CON EQUIPO | 28d | 2024-03-05 | 2024-04-01 | A4680 | 0d |  | HH [224 h] | Excavación |
| A6360 |  | PERFILADO EN ZONA DE CORTE EN FUNDACION Y TALUD | 14d | 2024-03-19 | 2024-04-01 | A6350 FF | 9d |  | HH [96 h] |  |
| A6370 |  | EXCAVACIÓN DE UÑA CON EQUIPO | 6d | 2024-03-28 | 2024-04-02 | A6350 FF+1d, A6360 SS | 0d |  | HH [48 h] | Excavación |
| A6380 |  | PREPARACIÓN DE FUNDACIÓN DE CUERPO DE DIQUE | 2d | 2024-04-02 | 2024-04-03 | A6350 SS, A6370 SS+5d | 0d |  | HH [16 h] |  |
| A6390 |  | CONFORMACIÓN DE CUERPO DE DIQUE CON MATERIAL PROPIO | 2d | 2024-04-02 | 2024-04-03 | A6380 SS | 0d |  | HH [16 h] | Relleno |
| A6410 |  | GEOTEXTIL NO TEJIDO 400 G/M2, INC. COLOCACIÓN | 5d | 2024-04-03 | 2024-04-07 | A6390 SS+1d | 0d |  | HH [40 h] |  |
| A6420 |  | COLOCACION Y ACOMODO DE ROCA EN UÑA DE DIQUE | 9d | 2024-04-03 | 2024-04-11 | A6410 SS | 0d |  | HH [72 h] | Roca |
| A6430 |  | COLOCACION Y ACOMODO DE ROCA EN TALUD DE DIQUE | 12d | 2024-04-03 | 2024-04-14 | A6420 SS | 0d |  | HH [96 h] | Roca |
| A6400 |  | PERFILADO Y COMPACTACIÓN EN ZONA DE CORTE EN CORONA | 4d | 2024-04-12 | 2024-04-15 | A6430 SS+9d | 0d |  | HH [32 h] |  |
| A6440 |  | CONFORMACIÓN DE MATERIAL GRANULAR EN CORONA DE DIQUE | 4d | 2024-04-12 | 2024-04-15 | A6430 FF+1d, A6400 SS | 0d |  | HH [32 h] | Relleno |

| ID | WBS | Activity | Duration | Start | Finish | Predecessors | Total float | Free float | Resources | Filtro |
| --- | --- | --- | --- | --- | --- | --- | --- | --- | --- | --- |
|  | 1 | **DIQUE DE TIERRA COMPACTADA A2-I-04 - TRAMO CON AFECTACIÓN** |  | 2024-09-06 | 2024-11-01 |  |  |  |  |  |
| A7650 |  | EXCAVACIÓN EN TERRENO NATURAL CON EQUIPO | 44d | 2024-09-06 | 2024-10-19 | A6340 | 16d | 0d | HH [352 h] | Excavación |
| A7740 |  | PERFILADO EN ZONA DE CORTE EN FUNDACION Y TALUD | 21d | 2024-09-29 | 2024-10-19 | A7650 FF | 29d | 14d | HH [152 h] |  |
| A7660 |  | EXCAVACIÓN DE UÑA CON EQUIPO | 8d | 2024-10-13 | 2024-10-20 | A7650 FF+1d, A7740 SS | 16d | 0d | HH [64 h] | Excavación |
| A7730 |  | PREPARACIÓN DE FUNDACIÓN DE CUERPO DE DIQUE | 2d | 2024-10-14 | 2024-10-15 | A7650 SS, A7660 SS+1d | 16d | 0d | HH [16 h] |  |
| A7680 |  | CONFORMACIÓN DE CUERPO DE DIQUE CON MATERIAL PROPIO | 3d | 2024-10-15 | 2024-10-17 | A7730 SS+1d | 16d | 0d | HH [24 h] | Relleno |
| A7700 |  | GEOTEXTIL NO TEJIDO 400 G/M2, INC. COLOCACIÓN | 7d | 2024-10-16 | 2024-10-22 | A7680 SS+1d | 16d | 0d | HH [56 h] |  |
| A7710 |  | COLOCACION Y ACOMODO DE ROCA EN UÑA DE DIQUE | 14d | 2024-10-16 | 2024-10-29 | A7700 SS | 16d | 0d | HH [112 h] | Roca |
| A7720 |  | COLOCACION Y ACOMODO DE ROCA EN TALUD DE DIQUE | 14d | 2024-10-16 | 2024-10-29 | A7710 SS | 16d | 0d | HH [112 h] | Roca |
| A7670 |  | PERFILADO Y COMPACTACIÓN EN ZONA DE CORTE EN CORONA | 5d | 2024-10-26 | 2024-10-30 | A7720 FF+1d | 16d | 0d | HH [40 h] |  |
| A7690 |  | CONFORMACIÓN DE MATERIAL GRANULAR EN CORONA DE DIQUE | 7d | 2024-10-26 | 2024-11-01 | A7720 FF+1d, A7670 SS | 16d |  | HH [56 h] | Relleno |
|  | 5 | **DIQUE DE TIERRA COMPACTADA A2-D-3** |  | 2024-04-16 | 2024-11-15 |  |  |  |  |  |
|  | 8 | **DIQUE DE TIERRA COMPACTADA A2-D-03 - TRAMO SIN AFECTACIÓN** |  | 2024-04-16 | 2024-06-05 |  |  |  |  |  |
| A6450 |  | EXCAVACIÓN EN TERRENO NATURAL CON EQUIPO | 34d | 2024-04-16 | 2024-05-19 | A6440 | 0d |  | HH [272 h] | Excavación |
| A6460 |  | PERFILADO EN ZONA DE CORTE EN FUNDACION Y TALUD | 19d | 2024-05-02 | 2024-05-20 | A6450 FF+1d | 12d |  | HH [128 h] |  |
| A6470 |  | EXCAVACIÓN DE UÑA CON EQUIPO | 6d | 2024-05-16 | 2024-05-21 | A6450 FF+2d, A6460 SS+2d | 0d |  | HH [48 h] | Excavación |
| A6480 |  | PREPARACIÓN DE FUNDACIÓN DE CUERPO DE DIQUE | 2d | 2024-05-18 | 2024-05-19 | A6450 SS+6d, A6470 SS+2d | 0d |  | HH [16 h] |  |
| A6490 |  | CONFORMACIÓN DE CUERPO DE DIQUE CON MATERIAL PROPIO | 2d | 2024-05-18 | 2024-05-19 | A6480 SS | 0d |  | HH [16 h] | Relleno |
| A6500 |  | PERFILADO Y COMPACTACIÓN EN ZONA DE CORTE | 6d | 2024-05-19 | 2024-05-24 | A6490 SS+1d | 0d |  | HH [48 h] |  |
| A6510 |  | GEOTEXTIL NO TEJIDO 400 G/M2, INC. COLOCACIÓN | 5d | 2024-05-20 | 2024-05-24 | A6490 SS+2d, A6500 SS+1d | 0d |  | HH [40 h] |  |
| A6520 |  | COLOCACION Y ACOMODO DE ROCA EN UÑA DE DIQUE | 10d | 2024-05-21 | 2024-05-30 | A6510 SS+1d | 0d |  | HH [80 h] | Roca |
| A6530 |  | COLOCACION Y ACOMODO DE ROCA EN TALUD DE DIQUE | 14d | 2024-05-22 | 2024-06-04 | A6520 SS+1d | 0d |  | HH [112 h] | Roca |
| A6540 |  | CONFORMACIÓN DE MATERIAL GRANULAR EN CORONA DE DIQUE | 5d | 2024-06-01 | 2024-06-05 | A6530 FF+1d | 0d |  | HH [40 h] | Relleno |
|  | 7 | **DIQUE DE TIERRA COMPACTADA A2-D-03 - TRAMO CON AFECTACIÓN** |  | 2024-10-07 | 2024-11-15 |  |  |  |  |  |
| A7050 |  | EXCAVACIÓN EN TERRENO NATURAL CON EQUIPO | 21d | 2024-10-07 | 2024-10-27 | A7340, A6840 | 0d |  | HH [168 h] | Excavación |
| A7060 |  | PERFILADO EN ZONA DE CORTE EN FUNDACION Y TALUD | 21d | 2024-10-09 | 2024-10-29 | A7050 FF+2d | 14d |  | HH [152 h] |  |
| A7070 |  | EXCAVACIÓN DE UÑA CON EQUIPO | 7d | 2024-10-24 | 2024-10-30 | A7050 FF+3d, A7060 SS+1d | 0d |  | HH [56 h] | Excavación |
| A7080 |  | PREPARACIÓN DE FUNDACIÓN DE CUERPO DE DIQUE | 3d | 2024-10-26 | 2024-10-28 | A7050 SS, A7070 SS+2d | 0d |  | HH [24 h] |  |
| A7090 |  | CONFORMACIÓN DE CUERPO DE DIQUE CON MATERIAL PROPIO | 3d | 2024-10-29 | 2024-10-31 | A7080 SS+3d | 0d |  | HH [24 h] | Relleno |
| A7100 |  | PERFILADO Y COMPACTACIÓN EN ZONA DE CORTE | 7d | 2024-10-30 | 2024-11-05 | A7090 SS+1d | 0d |  | HH [56 h] |  |
| A7110 |  | GEOTEXTIL NO TEJIDO 400 G/M2, INC. COLOCACIÓN | 6d | 2024-11-01 | 2024-11-06 | A7090 SS+1d, A7100 SS+2d | 0d |  | HH [48 h] |  |
| A7120 |  | COLOCACION Y ACOMODO DE ROCA EN UÑA DE DIQUE | 11d | 2024-11-02 | 2024-11-12 | A7110 SS+1d | 0d |  | HH [88 h] | Roca |
| A7130 |  | CONFORMACIÓN DE MATERIAL GRANULAR EN CORONA DE DIQUE | 12d | 2024-11-03 | 2024-11-14 | A7120 SS+1d | 0d |  | HH [96 h] | Roca |
| A7140 |  | CONFORMACIÓN DE CORONA DE DIQUE CON MATERIAL PROPIO | 7d | 2024-11-09 | 2024-11-15 | A7130 FF+1d | 0d |  | HH [56 h] | Relleno |

| ID | WBS | Activity | Duration | Start | Finish | Predecessors | Total float | Free float | Resources | Filtro |
| --- | --- | --- | --- | --- | --- | --- | --- | --- | --- | --- |
|  | 8 | **DIQUE DE TIERRA COMPACTADA A2-D-4** |  | 2024-06-06 | 2024-09-23 |  |  |  |  |  |
|  | 1 | **DIQUE DE TIERRA COMPACTADA A2-D-4 - TRAMO SIN AFECTACION** |  | 2024-06-06 | 2024-06-13 |  |  |  |  |  |
| A7750 |  | EXCAVACIÓN EN TERRENO NATURAL CON EQUIPO | 3d | 2024-06-06 | 2024-06-08 | A6540 | 0d |  | HH [24 h] | Excavación |
| A7840 |  | PERFILADO EN ZONA DE CORTE EN FUNDACION Y TALUD | 3d | 2024-06-06 | 2024-06-08 | A7750 FF | 1d |  | HH [24 h] |  |
| A7760 |  | EXCAVACIÓN DE UÑA CON EQUIPO | 2d | 2024-06-08 | 2024-06-09 | A7750 FF+1d, A7840 SS+1d | 0d |  | HH [16 h] | Excavación |
| A7780 |  | CONFORMACIÓN DE CUERPO DE DIQUE CON MATERIAL PROPIO | 2d | 2024-06-09 | 2024-06-10 | A7830 SS | 0d |  | HH [16 h] | Relleno |
| A7830 |  | PREPARACIÓN DE FUNDACIÓN DE CUERPO DE DIQUE | 1d | 2024-06-09 | 2024-06-09 | A7750 SS+1d, A7760 SS+1d | 0d |  | HH [8 h] |  |
| A7770 |  | PERFILADO Y COMPACTACIÓN EN ZONA DE CORTE | 3d | 2024-06-10 | 2024-06-12 | A7780 SS+1d | 0d |  | HH [24 h] |  |
| A7790 |  | CONFORMACIÓN DE MATERIAL GRANULAR EN CORONA DE DIQUE | 3d | 2024-06-10 | 2024-06-12 | A7770 SS | 158d |  | HH [24 h] | Relleno |
| A7800 |  | GEOTEXTIL NO TEJIDO 400 G/M2, INC. COLOCACIÓN | 2d | 2024-06-11 | 2024-06-12 | A7780 SS+1d, A7770 SS+1d | 0d |  | HH [16 h] |  |
| A7810 |  | COLOCACION Y ACOMODO DE ROCA EN UÑA DE DIQUE | 2d | 2024-06-12 | 2024-06-13 | A7800 SS+1d | 0d |  | HH [16 h] | Roca |
| A7820 |  | COLOCACION Y ACOMODO DE ROCA EN TALUD DE DIQUE | 2d | 2024-06-12 | 2024-06-13 | A7810 SS | 0d |  | HH [16 h] | Roca |
|  | 12 | **DIQUE DE TIERRA COMPACTADA A2-D-4 - TRAMO CON AFECTACIÓN** |  | 2024-09-07 | 2024-09-23 |  |  |  |  |  |
| A6750 |  | EXCAVACIÓN EN TERRENO NATURAL CON EQUIPO | 7d | 2024-09-07 | 2024-09-13 | A7040 | 13d | 0d | HH [56 h] | Excavación |
| A6760 |  | PERFILADO EN ZONA DE CORTE EN FUNDACION Y TALUD | 7d | 2024-09-07 | 2024-09-13 | A6750 FF | 17d | 4d | HH [56 h] |  |
| A6770 |  | EXCAVACIÓN DE UÑA CON EQUIPO | 3d | 2024-09-12 | 2024-09-14 | A6750 FF+1d, A6760 SS+1d | 13d | 0d | HH [24 h] | Excavación |
| A6780 |  | PREPARACIÓN DE FUNDACIÓN DE CUERPO DE DIQUE | 1d | 2024-09-13 | 2024-09-13 | A6750 SS+6d, A6770 SS+1d | 13d | 0d | HH [8 h] |  |
| A6790 |  | CONFORMACIÓN DE CUERPO DE DIQUE CON MATERIAL PROPIO | 3d | 2024-09-14 | 2024-09-16 | A6780 SS+1d | 13d | 0d | HH [24 h] | Relleno |
| A6800 |  | PERFILADO Y COMPACTACIÓN EN ZONA DE CORTE | 2d | 2024-09-15 | 2024-09-16 | A6790 SS+1d | 13d | 0d | HH [16 h] |  |
| A6810 |  | GEOTEXTIL NO TEJIDO 400 G/M2, INC. COLOCACIÓN | 3d | 2024-09-16 | 2024-09-18 | A6790 SS+1d, A6800 SS+1d | 13d | 0d | HH [24 h] |  |
| A6820 |  | COLOCACION Y ACOMODO DE ROCA EN UÑA DE DIQUE | 5d | 2024-09-17 | 2024-09-21 | A6810 SS+1d | 13d | 0d | HH [40 h] | Roca |
| A6830 |  | COLOCACION Y ACOMODO DE ROCA EN TALUD DE DIQUE | 6d | 2024-09-17 | 2024-09-22 | A6820 SS | 13d | 0d | HH [48 h] | Roca |
| A6840 |  | CONFORMACIÓN DE MATERIAL GRANULAR EN CORONA DE DIQUE | 2d | 2024-09-22 | 2024-09-23 | A6830 FF+1d | 13d |  | HH [16 h] | Relleno |
|  | 3 | **DIQUE DE TIERRA COMPACTADA A2-D-5** |  | 2024-06-06 | 2024-10-06 |  |  |  |  |  |
|  | 17 | **DIQUE DE TIERRA COMPACTADA A2-D-5 - TRAMO SIN AFECTACIÓN** |  | 2024-06-06 | 2024-07-01 |  |  |  |  |  |
| A6550 |  | EXCAVACIÓN EN TERRENO NATURAL CON EQUIPO | 18d | 2024-06-06 | 2024-06-23 | A6540 | 5d | 0d | HH [144 h] | Excavación |
| A6560 |  | PERFILADO EN ZONA DE CORTE EN FUNDACION Y TALUD | 9d | 2024-06-16 | 2024-06-24 | A6550 SS+10d | 9d | 4d | HH [64 h] |  |
| A6570 |  | EXCAVACIÓN DE UÑA CON EQUIPO | 4d | 2024-06-21 | 2024-06-24 | A6550 FF+1d, A6560 SS+1d | 5d | 0d | HH [32 h] | Excavación |
| A6580 |  | PREPARACIÓN DE FUNDACIÓN DE CUERPO DE DIQUE | 2d | 2024-06-23 | 2024-06-24 | A6550 SS, A6570 SS+2d | 5d | 0d | HH [16 h] |  |
| A6590 |  | CONFORMACIÓN DE CUERPO DE DIQUE CON MATERIAL PROPIO | 3d | 2024-06-23 | 2024-06-25 | A6580 SS | 5d | 0d | HH [24 h] | Relleno |
| A6600 |  | PERFILADO Y COMPACTACIÓN EN ZONA DE CORTE | 3d | 2024-06-23 | 2024-06-25 | A6590 SS | 5d | 0d | HH [24 h] |  |
| A6610 |  | GEOTEXTIL NO TEJIDO 400 G/M2, INC. COLOCACIÓN | 3d | 2024-06-24 | 2024-06-26 | A6590 SS+1d, A6600 SS+1d | 5d | 0d | HH [24 h] |  |
| A6620 |  | COLOCACION Y ACOMODO DE ROCA EN UÑA DE DIQUE | 7d | 2024-06-24 | 2024-06-30 | A6610 SS | 5d | 0d | HH [56 h] | Roca |
| A6630 |  | COLOCACION Y ACOMODO DE ROCA EN TALUD DE DIQUE | 7d | 2024-06-24 | 2024-06-30 | A6620 SS | 5d | 0d | HH [56 h] | Roca |
| A6640 |  | CONFORMACIÓN DE MATERIAL GRANULAR EN CORONA DE DIQUE | 3d | 2024-06-29 | 2024-07-01 | A6630 FF+1d | 5d | 0d | HH [24 h] | Relleno |

| ID | WBS | Activity | Duration | Start | Finish | Predecessors | Total float | Resources | Filtro |
| --- | --- | --- | --- | --- | --- | --- | --- | --- | --- |
|  | 16 | **DIQUE DE TIERRA COMPACTADA A2-D-5 - TRAMO CON AFECTACIÓN** |  | 2024-09-07 | 2024-10-06 |  |  |  |  |
| A7250 |  | EXCAVACIÓN EN TERRENO NATURAL CON EQUIPO | 18d | 2024-09-07 | 2024-09-24 | A7040 | 0d | HH [144 h] | Excavación |
| A7260 |  | PERFILADO EN ZONA DE CORTE EN FUNDACION Y TALUD | 10d | 2024-09-16 | 2024-09-25 | A7250 FF+1d | 7d | HH [72 h] |  |
| A7270 |  | EXCAVACIÓN DE UÑA CON EQUIPO | 4d | 2024-09-23 | 2024-09-26 | A7250 FF+2d, A7260 SS | 0d | HH [32 h] | Excavación |
| A7280 |  | PREPARACIÓN DE FUNDACIÓN DE CUERPO DE DIQUE | 2d | 2024-09-24 | 2024-09-25 | A7250 SS+6d, A7270 SS+1d | 0d | HH [16 h] |  |
| A7290 |  | CONFORMACIÓN DE CUERPO DE DIQUE CON MATERIAL PROPIO | 3d | 2024-09-25 | 2024-09-27 | A7280 SS+1d | 0d | HH [24 h] | Relleno |
| A7300 |  | PERFILADO Y COMPACTACIÓN EN ZONA DE CORTE | 3d | 2024-09-26 | 2024-09-28 | A7290 SS+1d | 0d | HH [24 h] |  |
| A7310 |  | GEOTEXTIL NO TEJIDO 400 G/M2, INC. COLOCACIÓN | 3d | 2024-09-27 | 2024-09-29 | A7290 SS+1d, A7300 SS+1d | 0d | HH [24 h] |  |
| A7320 |  | COLOCACION Y ACOMODO DE ROCA EN UÑA DE DIQUE | 7d | 2024-09-28 | 2024-10-04 | A7310 SS+1d | 0d | HH [56 h] | Roca |
| A7330 |  | COLOCACION Y ACOMODO DE ROCA EN TALUD DE DIQUE | 7d | 2024-09-29 | 2024-10-05 | A7320 SS+1d | 0d | HH [56 h] | Roca |
| A7340 |  | CONFORMACIÓN DE MATERIAL GRANULAR EN CORONA DE DIQUE | 3d | 2024-10-04 | 2024-10-06 | A7330 FF+1d | 0d | HH [24 h] | Relleno |
|  | 9 | **DIQUE DE TIERRA COMPACTADA A2-D-6** |  | 2024-06-14 | 2024-11-12 |  |  |  |  |
|  | 15 | **DIQUE DE TIERRA COMPACTADA A2-D-06 - TRAMO SIN AFECTACIÓN** |  | 2024-06-14 | 2024-07-01 |  |  |  |  |
| A5050 |  | EXCAVACIÓN EN TERRENO NATURAL CON EQUIPO | 10d | 2024-06-14 | 2024-06-23 | A7820 | 0d | HH [80 h] | Excavación |
| A6080 |  | PERFILADO EN ZONA DE CORTE EN FUNDACION Y TALUD | 9d | 2024-06-15 | 2024-06-23 | A5050 FF | 5d | HH [56 h] |  |
| A5060 |  | EXCAVACIÓN DE UÑA CON EQUIPO | 4d | 2024-06-21 | 2024-06-24 | A5050 FF+1d, A6080 SS+1d | 0d | HH [32 h] | Excavación |
| A5080 |  | PREPARACIÓN DE FUNDACIÓN DE CUERPO DE DIQUE | 2d | 2024-06-21 | 2024-06-22 | A5050 SS, A5060 SS | 0d | HH [16 h] |  |
| A5070 |  | PERFILADO Y COMPACTACIÓN EN ZONA DE CORTE | 2d | 2024-06-22 | 2024-06-23 | A5050 SS+2d, A5060 SS+1d | 1d | HH [16 h] |  |
| A5090 |  | CONFORMACIÓN DE CUERPO DE DIQUE CON MATERIAL PROPIO | 6d | 2024-06-22 | 2024-06-27 | A5080 SS+1d | 0d | HH [48 h] | Relleno |
| A5100 |  | GEOTEXTIL NO TEJIDO 400 G/M2, INC. COLOCACIÓN | 3d | 2024-06-25 | 2024-06-27 | A5070 SS+2d, A5090 FF | 0d | HH [24 h] |  |
| A5110 |  | COLOCACION Y ACOMODO DE ROCA EN UÑA DE DIQUE | 7d | 2024-06-25 | 2024-07-01 | A5100 SS | 0d | HH [56 h] | Roca |
| A5120 |  | COLOCACION Y ACOMODO DE ROCA EN TALUD DE DIQUE | 6d | 2024-06-25 | 2024-06-30 | A5110 SS | 0d | HH [48 h] | Roca |
| A5130 |  | CONFORMACIÓN DE MATERIAL GRANULAR EN CORONA DE DIQUE | 3d | 2024-06-29 | 2024-07-01 | A5120 FF+1d | 0d | HH [24 h] | Relleno |
|  | 14 | **DIQUE DE TIERRA COMPACTADA A2-D-06 - TRAMO CON AFECTACIÓN** |  | 2024-07-02 | 2024-09-06 |  |  |  |  |
| A6950 |  | EXCAVACIÓN EN TERRENO NATURAL CON EQUIPO | 35d | 2024-07-02 | 2024-08-05 | A5130 | 0d | HH [280 h] | Excavación |
| A6960 |  | PERFILADO EN ZONA DE CORTE EN FUNDACION Y TALUD | 28d | 2024-07-10 | 2024-08-06 | A6950 FF+1d | 14d | HH [200 h] |  |
| A6970 |  | EXCAVACIÓN DE UÑA CON EQUIPO | 13d | 2024-07-26 | 2024-08-07 | A6950 FF+2d, A6960 SS+2d | 0d | HH [104 h] | Excavación |
| A6980 |  | PREPARACIÓN DE FUNDACIÓN DE CUERPO DE DIQUE | 6d | 2024-07-27 | 2024-08-01 | A6950 SS+6d, A6970 SS+1d | 0d | HH [48 h] |  |
| A6990 |  | CONFORMACIÓN DE CUERPO DE DIQUE CON MATERIAL PROPIO | 21d | 2024-07-28 | 2024-08-17 | A6980 SS+1d | 0d | HH [168 h] | Relleno |
| A7000 |  | PERFILADO Y COMPACTACIÓN EN ZONA DE CORTE | 2d | 2024-07-28 | 2024-07-29 | A6990 SS | 10d | HH [16 h] |  |
| A7010 |  | GEOTEXTIL NO TEJIDO 400 G/M2, INC. COLOCACIÓN | 10d | 2024-08-08 | 2024-08-17 | A6990 FF, A7000 SS+1d | 0d | HH [80 h] |  |
| A7020 |  | COLOCACION Y ACOMODO DE ROCA EN UÑA DE DIQUE | 23d | 2024-08-09 | 2024-08-31 | A7010 SS+1d | 0d | HH [184 h] | Roca |
| A7030 |  | COLOCACION Y ACOMODO DE ROCA EN TALUD DE DIQUE | 28d | 2024-08-09 | 2024-09-05 | A7020 SS | 0d | HH [224 h] | Roca |
| A7040 |  | CONFORMACIÓN DE MATERIAL GRANULAR EN CORONA DE DIQUE | 10d | 2024-08-28 | 2024-09-06 | A7030 FF+1d | 0d | HH [80 h] | Relleno |

| ID | WBS | Activity | Duration | Start | Finish | Predecessors | Total float | Free float | Resources | Filtro |
| --- | --- | --- | --- | --- | --- | --- | --- | --- | --- | --- |
|  | 13 | **DIQUE DE TIERRA COMPACTADA A2-D-06 - TRAMO POR LIBERAR 01 17+839** |  | 2024-10-25 | 2024-11-12 |  |  |  |  |  |
| A7450 |  | EXCAVACIÓN EN TERRENO NATURAL CON EQUIPO | 7d | 2024-10-25 | 2024-10-31 | A7440 | 5d | 0d | HH [56 h] | Excavación |
| A7460 |  | PERFILADO EN ZONA DE CORTE EN FUNDACION Y TALUD | 6d | 2024-10-27 | 2024-11-01 | A7450 FF+1d | 8d | 3d | HH [40 h] |  |
| A7470 |  | EXCAVACIÓN DE UÑA CON EQUIPO | 3d | 2024-10-31 | 2024-11-02 | A7450 FF+2d, A7460 SS+1d | 5d | 0d | HH [24 h] | Excavación |
| A7490 |  | PERFILADO Y COMPACTACIÓN EN ZONA DE CORTE | 2d | 2024-11-01 | 2024-11-02 | A7450 SS+3d, A7470 SS+1d | 7d | 2d | HH [16 h] |  |
| A7480 |  | PREPARACIÓN DE FUNDACIÓN DE CUERPO DE DIQUE | 2d | 2024-11-02 | 2024-11-03 | A7450 SS+3d, A7470 FF+1d | 5d | 0d | HH [16 h] |  |
| A7500 |  | CONFORMACIÓN DE CUERPO DE DIQUE CON MATERIAL PROPIO | 4d | 2024-11-03 | 2024-11-06 | A7480 SS+1d | 5d | 0d | HH [32 h] | Relleno |
| A7510 |  | GEOTEXTIL NO TEJIDO 400 G/M2, INC. COLOCACIÓN | 3d | 2024-11-05 | 2024-11-07 | A7490 SS+2d, A7500 SS+2d | 5d | 0d | HH [24 h] |  |
| A7520 |  | COLOCACION Y ACOMODO DE ROCA EN UÑA DE DIQUE | 5d | 2024-11-06 | 2024-11-10 | A7510 SS+1d | 5d | 0d | HH [40 h] | Roca |
| A7530 |  | COLOCACION Y ACOMODO DE ROCA EN TALUD DE DIQUE | 5d | 2024-11-07 | 2024-11-11 | A7520 SS+1d | 5d | 0d | HH [40 h] | Roca |
| A7540 |  | CONFORMACIÓN DE MATERIAL GRANULAR EN CORONA DE DIQUE | 3d | 2024-11-10 | 2024-11-12 | A7530 FF+1d | 5d |  | HH [24 h] | Relleno |
|  | 6 | **RAMPAS** |  | 2024-02-09 | 2024-11-14 |  |  |  |  |  |
|  | 2 | **CONSTRUCCIÓN DE RAMPAS** |  | 2024-02-09 | 2024-11-14 |  |  |  |  |  |
| A6040 |  | EXCAVACIÓN EN TERRENO NATURAL CON EQUIPO | 270d | 2024-02-09 | 2024-11-04 | A5820 | 3d | 0d |  |  |
| A6050 |  | CONFORMACIÓN DE CUERPO DE RAMPA CON MATERIAL PROPIO | 272d | 2024-02-11 | 2024-11-08 | A6040 SS+2d | 3d | 0d |  |  |
| A5940 |  | CONFORMACIÓN DE CORONA DE RAMPA | 274d | 2024-02-15 | 2024-11-14 | A6050 SS+4d | 3d |  | HH [48 h] |  |
|  | 7 | **OBRAS DE ARTE** |  | 2024-02-13 | 2024-11-07 |  |  |  |  |  |
|  | 1 | **CAPTACIONES** |  | 2024-02-13 | 2024-08-26 |  |  |  |  |  |
|  | 1 | **MOVIMIENTO DE TIERRAS** |  | 2024-02-13 | 2024-03-01 |  |  |  |  |  |
| A2770 |  | EXCAVACIÓN ESTRUCTURAL PARA OBRAS DE ARTE | 18d | 2024-02-13 | 2024-03-01 | A5860 | 83d | 0d | HH [144 h] |  |
| A2780 |  | RELLENO ESTRUCTURAL PARA OBRAS DE ARTE, CON MATERIAL PROPIO | 6d | 2024-02-25 | 2024-03-01 | A2770 FF | 101d | 18d | HH [48 h] |  |
|  | 2 | **OBRAS DE CONCRETO** |  | 2024-03-02 | 2024-04-18 |  |  |  |  |  |
| A2790 |  | CONCRETO f'c=100 kg/cm2 | 3d | 2024-03-02 | 2024-03-04 | A2770 | 83d | 0d | HH [24 h] |  |
| A2810 |  | CONCRETO CICLÓPEO f'c=280 kg/cm2 + 30% P.G. | 2d | 2024-03-07 | 2024-03-08 | A2790 SS+5d | 83d | 0d | HH [16 h] |  |
| A2830 |  | ACERO DE REFUERZO fy=4200 kg/cm2 | 40d | 2024-03-07 | 2024-04-15 | A2810 SS | 83d | 0d | HH [320 h] |  |
| A2800 |  | CONCRETO f'c=280 kg/cm2 | 40d | 2024-03-10 | 2024-04-18 | A2820 FF | 83d | 0d | HH [320 h] |  |
| A2820 |  | ENCOFRADO Y DESENCOFRADO RECTO | 30d | 2024-03-20 | 2024-04-18 | A2830 FF+3d, A2780 | 83d | 0d | HH [240 h] |  |

| ID | WBS | Activity | Duration | Start | Finish | Predecessors | Total float | Free float | Resources |
| --- | --- | --- | --- | --- | --- | --- | --- | --- | --- |
|  | 3 | **ESTRUCTURAS METALICAS** |  | 2024-04-19 | 2024-04-30 |  |  |  |  |
| A2840 |  | COMPUERTA METALICA PLANA DESLIZANTE DE 1.0x1.0m | 2d | 2024-04-19 | 2024-04-20 | A2800 | 83d | 0d | HH [16 h] |
| A2850 |  | REJILLA DE 1.00x1.00m CON VARILLA DE 1/2" CADA 6,25cm | 2d | 2024-04-21 | 2024-04-22 | A2840 | 83d | 0d | HH [16 h] |
| A2860 |  | BARANDA DE FIERRO GALVANIZADO 1 1/2" | 2d | 2024-04-23 | 2024-04-24 | A2850 | 83d | 0d | HH [16 h] |
| A2870 |  | ESCALERA TIPO GATO | 4d | 2024-04-25 | 2024-04-28 | A2860 | 83d | 0d | HH [32 h] |
| A2880 |  | TAPA METALICA CIRCULAR DN600 MM | 2d | 2024-04-29 | 2024-04-30 | A2870 | 83d | 0d | HH [16 h] |
|  | 4 | **TUBERIAS** |  | 2024-05-01 | 2024-06-28 |  |  |  |  |
| A2890 |  | EXCAVACIÓN ESTRUCTURAL PARA OBRAS DE ARTE (Buzones) | 2d | 2024-05-01 | 2024-05-02 | A2880 | 83d | 0d | HH [16 h] |
| A2900 |  | EXCAVACIÓN DE ZANJA | 30d | 2024-05-03 | 2024-06-01 | A2890 | 83d | 0d | HH [240 h] |
| A2920 |  | CAMA DE ARENA | 6d | 2024-06-02 | 2024-06-07 | A2900 | 142d | 0d | HH [48 h] |
| A2940 |  | CONCRETO f'c=100 kg/cm2 (Buzones) | 2d | 2024-06-02 | 2024-06-03 | A2900 | 83d | 0d | HH [16 h] |
| A2990 |  | SUMINISTRO E INSTALACIÓN DE TUBERÍA GRP DN600 mm SN2500 | 5d | 2024-06-03 | 2024-06-07 | A2920 SS+1d | 142d | 0d | HH [40 h] |
| A2980 |  | ACERO DE REFUERZO fy=4200 kg/cm2 (Buzones) | 4d | 2024-06-04 | 2024-06-07 | A2940 | 83d | 0d | HH [32 h] |
| A2950 |  | CONCRETO f'c=280 kg/cm2 (Buzones) | 2d | 2024-06-08 | 2024-06-09 | A2970 SS | 124d | 41d | HH [16 h] |
| A2960 |  | ENCOFRADO Y DESENCOFRADO RECTO | 3d | 2024-06-08 | 2024-06-10 | A2980 | 83d | 0d | HH [24 h] |
| A2970 |  | ENCOFRADO Y DESENCOFRADO CURVO | 6d | 2024-06-08 | 2024-06-13 | A2960 SS | 83d | 0d | HH [48 h] |
| A2930 |  | RELLENO SELECCIONADO PARA ZANJA con material propio | 16d | 2024-06-10 | 2024-06-25 | A2990 FS+2d | 142d | 0d | HH [128 h] |
| A2910 |  | RELLENO ESTRUCTURAL PARA OBRAS DE ARTE, CON MATERIAL PROPIO | 3d | 2024-06-26 | 2024-06-28 | A2930 | 142d |  | HH [24 h] |
|  | 5 | **CANAL** |  | 2024-06-02 | 2024-08-08 |  |  |  |  |
| A3000 |  | EXCAVACIÓN ESTRUCTURAL PARA CANALES | 18d | 2024-06-02 | 2024-06-19 | A2900 | 112d | 29d | HH [144 h] |
| A3040 |  | ENCOFRADO Y DESENCOFRADO RECTO | 33d | 2024-06-14 | 2024-07-16 | A2970 | 83d | 0d | HH [264 h] |
| A3020 |  | COLOCACIÓN DE CONCRETO f'c=100 kg/cm2 | 2d | 2024-07-17 | 2024-07-18 | A3040 | 83d | 0d | HH [16 h] |
| A3030 |  | COLOCACIÓN DE CONCRETO f'c=280 kg/cm2 | 8d | 2024-07-19 | 2024-07-26 | A2950 SS, A3040 FF, A3020, A3000 | 83d | 0d | HH [64 h] |
| A3060 |  | JUNTA WATER STOP SIN BULBO 150 mm | 2d | 2024-07-25 | 2024-07-26 | A3030 FF, A3020 | 83d | 0d | HH [16 h] |
| A3010 |  | RELLENO ESTRUCTURAL PARA CANALES, CON MATERIAL PROPIO | 13d | 2024-07-27 | 2024-08-08 | A3060 | 83d | 0d | HH [104 h] |

| ID | WBS | Activity | Duration | Start | Finish | Predecessors | Total float | Free float | Resources |
| --- | --- | --- | --- | --- | --- | --- | --- | --- | --- |
|  | 6 | **OBRAS DE DESCARGA** |  | 2024-08-09 | 2024-08-26 |  |  |  |  |
| A3070 |  | EXCAVACIÓN ESTRUCTURAL PARA OBRAS DE ARTE | 3d | 2024-08-09 | 2024-08-11 | A3010 | 83d | 0d | HH [24 h] |
| A3090 |  | CONCRETO f'c=100 kg/cm2 | 3d | 2024-08-12 | 2024-08-14 | A3070 | 83d | 0d | HH [24 h] |
| A3110 |  | ENCOFRADO Y DESENCOFRADO RECTO | 3d | 2024-08-15 | 2024-08-17 | A3090 | 92d |  | HH [24 h] |
| A3120 |  | ACERO DE REFUERZO fy=4200 kg/cm2 | 3d | 2024-08-15 | 2024-08-17 | A3090 | 83d | 0d | HH [24 h] |
| A3100 |  | CONCRETO f'c=280 kg/cm2 | 3d | 2024-08-18 | 2024-08-20 | A3120 | 83d | 0d | HH [24 h] |
| A3130 |  | JUNTA WATER STOP SIN BULBO 150 mm | 3d | 2024-08-21 | 2024-08-23 | A3100 | 83d | 0d | HH [24 h] |
| A3080 |  | RELLENO ESTRUCTURAL PARA OBRAS DE ARTE CON MATERIAL PROPIO | 3d | 2024-08-24 | 2024-08-26 | A3130 | 83d |  | HH [24 h] |
|  | 3 | **RETORNO Q=100 A 1000l/s** |  | 2024-02-13 | 2024-06-01 |  |  |  |  |
|  | 1 | **MOVIMIENTO DE TIERRAS** |  | 2024-02-13 | 2024-06-01 |  |  |  |  |
| A3460 |  | EXCAVACIÓN ESTRUCTURAL PARA OBRAS DE ARTE | 24d | 2024-02-13 | 2024-03-07 | A5860 | 169d | 0d | HH [192 h] |
| A3650 |  | CAMA DE ARENA | 2d | 2024-03-06 | 2024-03-07 | A7950 FF | 205d | 36d | HH |
| A3470 |  | RELLENO ESTRUCTURAL PARA OBRAS DE ARTE, CON MATERIAL PROPIO | 50d | 2024-04-13 | 2024-06-01 | A3490, A3650 | 169d |  | HH [400 h] |
|  | 2 | **OBRAS DE CONCRETO** |  | 2024-03-08 | 2024-04-12 |  |  |  |  |
| A3480 |  | CONCRETO f'c=100 kg/cm2 | 3d | 2024-03-08 | 2024-03-10 | A3460 | 169d | 0d | HH [24 h] |
| A3520 |  | ACERO DE REFUERZO fy=4200 kg/cm2 | 28d | 2024-03-11 | 2024-04-07 | A3460, A3480 | 169d | 0d | HH [224 h] |
| A3510 |  | ENCOFRADO Y DESENCOFRADO RECTO | 27d | 2024-03-17 | 2024-04-12 | A3520 SS+6d | 169d | 0d | HH [216 h] |
| A3490 |  | CONCRETO f'c=280 kg/cm2 | 8d | 2024-04-05 | 2024-04-12 | A3510 FF | 169d | 0d | HH [64 h] |
|  | 4 | **TUBERIAS** |  | 2024-03-06 | 2024-03-07 |  |  |  |  |
| A7950 |  | SUMINISTRO E INSTALACIÓN DE TUBERÍA HDPE DN600 mm | 2d | 2024-03-06 | 2024-03-07 | A3460 FF | 205d | 0d | HH |
|  | 3 | **COMPUESTAS Y VÁLVULAS** |  | 2024-04-13 | 2024-04-14 |  |  |  |  |
| A3540 |  | COMPUERTA TIPO CLAPETA DN600 mm | 2d | 2024-04-13 | 2024-04-14 | A3490 | 217d |  | HH [16 h] |
|  | 4 | **REPOSICIÓN DE CANALES** |  | 2024-07-02 | 2024-11-07 |  |  |  |  |
|  | 1 | **REPOSICIÓN DE CANALES** |  | 2024-07-02 | 2024-11-07 |  |  |  |  |
|  | 1 | **MOVIMIENTO DE TIERRAS** |  | 2024-07-02 | 2024-11-07 |  |  |  |  |
| A3560 |  | DEMOLICIÓN DE ESTRUCTURAS EXISTENTES | 51d | 2024-07-02 | 2024-08-21 | A6640 | 10d | 0d | HH [408 h] |
| A3570 |  | EXCAVACIÓN EN TERRENO NATURAL CON EQUIPO | 4d | 2024-08-18 | 2024-08-21 | A3560 FF | 10d | 0d | HH [32 h] |
| A3580 |  | RELLENO ESTRUCTURAL PARA OBRAS DE ARTE CON MATERIAL PROPIO | 2d | 2024-11-06 | 2024-11-07 | A3620 SS+10d | 10d |  | HH [16 h] |

| ID | WBS | Activity | Duration | Start | Finish | Predecessors | Total float | Free float | Resources |
| --- | --- | --- | --- | --- | --- | --- | --- | --- | --- |
|  | 2 | **OBRAS DE CONCRETO CANAL 1** |  | 2024-08-25 | 2024-10-30 |  |  |  |  |
| A3610 |  | CONCRETO f'c=100 kg/cm2 | 2d | 2024-08-25 | 2024-08-26 | A3570 SS+7d | 10d | 0d | HH [16 h] |
| A3600 |  | ACERO DE REFUERZO fy=4200 kg/cm2 | 26d | 2024-08-28 | 2024-09-22 | A3610 SS+3d | 10d | 0d | HH [208 h] |
| A3590 |  | ENCOFRADO Y DESENCOFRADO RECTO | 55d | 2024-09-04 | 2024-10-28 | A3600 SS+7d | 10d | 0d | HH [440 h] |
| A3620 |  | CONCRETO f'c=280 kg/cm2 | 2d | 2024-10-27 | 2024-10-28 | A3590 FF | 10d | 0d | HH [16 h] |
| A3630 |  | JUNTA WATER STOP 6" | 2d | 2024-10-29 | 2024-10-30 | A3620 FF+2d | 18d |  | HH [16 h] |
|  | 8 | **TRANSPORTE DE MATERIAL** |  | 2024-01-07 | 2024-11-15 |  |  |  |  |
| A5910 |  | TRANSPORTE DE MATERIAL EXCEDENTE PARA DISTANCIAS <1KM | 314d | 2024-01-07 | 2024-11-15 | A5780 SS | 2d | 0d | HH [2512 h] |
| A5920 |  | TRANSPORTE DE MATERIAL EXCEDENTE PARA DISTANCIAS >1KM | 314d | 2024-01-07 | 2024-11-15 | A5910 SS | 2d |  | HH [2512 h] |
| A5890 |  | TRANSPORTE DE ROCA PARA DISTANCIAS <1KM | 290d | 2024-01-31 | 2024-11-15 | A5840 SS | 2d | 0d | HH [2320 h] |
| A5900 |  | TRANSPORTE DE ROCA PARA DISTANCIAS >1KM | 290d | 2024-01-31 | 2024-11-15 | A5890 SS | 2d |  | HH [2320 h] |
| A5870 |  | TRANSPORTE DE MATERIAL GRANULAR PARA DISTANCIAS <1KM | 283d | 2024-02-07 | 2024-11-15 | A5860 SS | 2d | 0d | HH [2264 h] |
| A5880 |  | TRANSPORTE DE MATERIAL GRANULAR PARA DISTANCIAS >1KM | 283d | 2024-02-07 | 2024-11-15 | A5870 SS | 2d |  | HH [2264 h] |
|  | 9 | **ARQUITECTURA Y PAISAJISMO** |  | 2024-04-16 | 2024-11-03 |  |  |  |  |
|  | 6 | **INTERVENCION PAISAJISMO - CRUCE PAMPA DURA** |  | 2024-08-28 | 2024-11-03 |  |  |  |  |
|  | 1 | **OBRAS PRELIMINARES** |  | 2024-08-28 | 2024-10-09 |  |  |  |  |
| A3860 |  | MOVILIZACIÓN DE EQUIPOS Y HERRAMIENTAS (ARQUITECTURA Y PAISAJISMO) | 7d | 2024-08-28 | 2024-09-03 | A7040 SS | 14d | 0d | HH [56 h] |
| A3870 |  | TRAZO Y REPLANTEO PRELIMINAR | 2d | 2024-09-04 | 2024-09-05 | A3860 | 14d | 0d | HH [16 h] |
| A4020 |  | DEMOVILIZACIÓN DE EQUIPOS Y HERRAMIENTAS (ARQUITECTURA Y PAISAJISMO) | 7d | 2024-10-03 | 2024-10-09 | A4010, A3900 | 39d |  | HH [56 h] |
|  | 2 | **MOVIMIENTO DE TIERRAS** |  | 2024-09-06 | 2024-09-20 |  |  |  |  |
| A3880 |  | EXCAVACIÓN MANUAL PARA INSTALACIÓN DE BORDILLOS Y CIMENTACIONES | 2d | 2024-09-06 | 2024-09-07 | A3870 | 14d | 0d | HH [16 h] |
| A3900 |  | ELIMINACION DE MATERIAL EXCEDENTE (DME´S) | 2d | 2024-09-06 | 2024-09-07 | A3880 SS | 64d | 25d | HH [16 h] |
| A3890 |  | EXCAVACIÓN PARA MEJORAMIENTO DE SUELO CON TIERRA VEGETAL | 13d | 2024-09-08 | 2024-09-20 | A3880 | 14d | 0d | HH [104 h] |
|  | 3 | **PAVIMENTOS, RECUBRIMIENTOS Y BORDILLOS** |  | 2024-09-21 | 2024-09-29 |  |  |  |  |
| A3910 |  | PISO DE GRAVILLA | 2d | 2024-09-21 | 2024-09-22 | A3890 | 14d | 0d | HH [16 h] |
| A3920 |  | RECUBRIMIENTO DE PIEDRA DEL LUGAR e=0.05cm | 4d | 2024-09-23 | 2024-09-26 | A3910 | 14d | 0d | HH [32 h] |
| A3930 |  | BORDILLOS DE PIEDRA DEL LUGAR | 3d | 2024-09-27 | 2024-09-29 | A3920 | 14d | 0d | HH [24 h] |

| ID | WBS | Activity | Duration | Start | Finish | Predecessors | Total float | Free float | Resources |
| --- | --- | --- | --- | --- | --- | --- | --- | --- | --- |
|  | 4 | **MOBILIARIOS, BARANDAS Y ESCALERAS** |  | 2024-09-30 | 2024-11-03 |  |  |  |  |
| A3940 |  | ESCALERA DE CONCRETO SOBRE ENROCADO, CIMENTACION Y ANCLAJE | 10d | 2024-09-30 | 2024-10-09 | A3930 | 14d | 0d | HH [80 h] |
| A3950 |  | BARANDA DE MADERA EUCALIPTO CON SOGA, INCLUYE CIMENTACIÓN | 4d | 2024-10-10 | 2024-10-13 | A3940 | 14d | 0d | HH [32 h] |
| A3960 |  | TACHOS DE BASURA, INCLUYE CIMENTACIÓN | 3d | 2024-10-14 | 2024-10-16 | A3950 | 14d | 0d | HH [24 h] |
| A3970 |  | BANCAS DE CONCRETO, INCLUYE CIMENTACIÓN | 10d | 2024-10-17 | 2024-10-26 | A3960 | 14d | 0d | HH [80 h] |
| A3980 |  | POSTES DE ILUMINACIÓN, INCLUYE LUMINARIA Y CIMENTACIÓN | 5d | 2024-10-27 | 2024-10-31 | A3970 | 14d | 0d | HH [40 h] |
| A3990 |  | SEÑALETICA INFORMATIVA | 3d | 2024-11-01 | 2024-11-03 | A3980 | 14d |  | HH [24 h] |
|  | 5 | **INSTALACIÓN DE ALCORQUES** |  | 2024-09-30 | 2024-10-02 |  |  |  |  |
| A4010 |  | ALCORQUES DE PIEDRA DE CANTO RODADO PARA ARBOLES | 3d | 2024-09-30 | 2024-10-02 | A3930 | 39d | 0d | HH [24 h] |
|  | 1 | **INTERVENCION PAISAJISMO - TANGAY** |  | 2024-04-16 | 2024-06-01 |  |  |  |  |
|  | 1 | **OBRAS PRELIMINARES** |  | 2024-04-16 | 2024-05-09 |  |  |  |  |
| A7960 |  | MOVILIZACIÓN DE EQUIPOS Y HERRAMIENTAS (ARQUITECTURA Y PAISAJISMO) | 5d | 2024-04-16 | 2024-04-20 | A6440 | 169d | 0d | HH [40 h] |
| A7970 |  | TRAZO Y REPLANTEO PRELIMINAR | 2d | 2024-04-21 | 2024-04-22 | A7960 | 169d | 0d | HH [16 h] |
| A8120 |  | DEMOVILIZACIÓN DE EQUIPOS Y HERRAMIENTAS (ARQUITECTURA Y PAISAJISMO) | 5d | 2024-05-05 | 2024-05-09 | A8110, A8000 | 192d |  | HH [40 h] |
|  | 2 | **MOVIMIENTO DE TIERRAS** |  | 2024-04-23 | 2024-04-25 |  |  |  |  |
| A7980 |  | EXCAVACIÓN MANUAL PARA INSTALACIÓN DE BORDILLOS Y CIMENTACIONES | 1d | 2024-04-23 | 2024-04-23 | A7970 | 169d | 0d | HH [8 h] |
| A8000 |  | ELIMINACION DE MATERIAL EXCEDENTE (DME´S) | 1d | 2024-04-23 | 2024-04-23 | A7980 SS | 203d | 11d | HH [8 h] |
| A7990 |  | EXCAVACIÓN PARA MEJORAMIENTO DE SUELO CON TIERRA VEGETAL | 2d | 2024-04-24 | 2024-04-25 | A7980 | 169d | 0d | HH [16 h] |
|  | 3 | **PAVIMENTOS, RECUBRIMIENTOS Y BORDILLOS** |  | 2024-04-26 | 2024-05-02 |  |  |  |  |
| A8010 |  | PISO DE GRAVILLA | 1d | 2024-04-26 | 2024-04-26 | A7990 | 169d | 0d | HH [8 h] |
| A8020 |  | RECUBRIMIENTO DE PIEDRA DEL LUGAR e=0.05cm | 4d | 2024-04-27 | 2024-04-30 | A8010 | 169d | 0d | HH [32 h] |
| A8030 |  | BORDILLOS DE PIEDRA DEL LUGAR | 2d | 2024-05-01 | 2024-05-02 | A8020 | 169d | 0d | HH [16 h] |
|  | 4 | **MOBILIARIOS, BARANDAS Y ESCALERAS** |  | 2024-05-03 | 2024-06-01 |  |  |  |  |
| A8040 |  | ESCALERA DE CONCRETO SOBRE ENROCADO, CIMENTACION Y ANCLAJE | 10d | 2024-05-03 | 2024-05-12 | A8030 | 169d | 0d | HH [80 h] |
| A8050 |  | BARANDA DE MADERA EUCALIPTO CON SOGA, INCLUYE CIMENTACIÓN | 2d | 2024-05-13 | 2024-05-14 | A8040 | 169d | 0d | HH [16 h] |
| A8060 |  | TACHOS DE BASURA, INCLUYE CIMENTACIÓN | 3d | 2024-05-15 | 2024-05-17 | A8050 | 169d | 0d | HH [24 h] |
| A8070 |  | BANCAS DE CONCRETO, INCLUYE CIMENTACIÓN | 10d | 2024-05-18 | 2024-05-27 | A8060 | 169d | 0d | HH [80 h] |
| A8080 |  | POSTES DE ILUMINACIÓN, INCLUYE LUMINARIA Y CIMENTACIÓN | 3d | 2024-05-28 | 2024-05-30 | A8070 | 169d | 0d | HH [24 h] |
| A8090 |  | SEÑALETICA INFORMATIVA | 2d | 2024-05-31 | 2024-06-01 | A8080 | 169d |  | HH [16 h] |

| ID | WBS | Activity | Duration | Start | Finish | Predecessors | Total float | Free float | Resources | Filtro |
| --- | --- | --- | --- | --- | --- | --- | --- | --- | --- | --- |
|  | 5 | **INSTALACIÓN DE ALCORQUES** |  | 2024-05-03 | 2024-05-04 |  |  |  |  |  |
| A8110 |  | ALCORQUES DE PIEDRA DE CANTO RODADO PARA ARBOLES | 2d | 2024-05-03 | 2024-05-04 | A8030 | 192d | 0d | HH [16 h] |  |
|  | 10 | **PROGRAMA DE CIERRE DE OBRA** |  | 2024-01-07 | 2024-11-15 |  |  |  |  |  |
| A1770 |  | ACONDICIONAMIENTO DE DEPOSITOS DE MATERIALES EXCEDENTES (DME) | 314d | 2024-01-07 | 2024-11-15 | A4240 SS | 2d | 0d | HH [2512 h] | Excavación |
| A1780 |  | RESTAURACIÓN DE ÁREAS DE INSTALACIONES PROVISIONALES | 24d | 2024-10-23 | 2024-11-15 | A1770 SS+290d | 2d |  | HH [192 h] |  |
